# BB-08 - met dragend metselwerk

Schedule from MS Project, 2003-01-12 to 2003-01-31, status date 2003-01-08.
BAM Nelissen Van Egteren

## Calendars

- ALLEEN WERKDAGEN: Mon-Fri 08:30-12:30, 13:00-17:00; Sat-Sun off. Exceptions (off unless hours are given): 2003-01-11 to 2003-01-12 08:30-12:30, 13:00-17:00, 2003-01-18 to 2003-01-19 08:30-12:30, 13:00-17:00, 2003-01-25 to 2003-01-26 08:30-12:30, 13:00-17:00.

## Schedule

| ID | WBS | Task | Type | Duration | Start | Finish | Predecessors | Total slack |
| --- | --- | --- | --- | --- | --- | --- | --- | --- |
| 1 | 1 | **BOVENBOUWFASE** |  | 20d | 2003-01-12 | 2003-01-31 |  | 0d |
| 2 | 1.1 | beg.grond kozijnen+profielen |  | 4d | 2003-01-12 | 2003-01-15 |  | 0d |
| 3 | 1.2 | beg.grond metselen 1e slag |  | 7d | 2003-01-16 | 2003-01-22 | 2SS+4d | 0d |
| 4 | 1.3 | metselsteiger opbouwen |  | 2d | 2003-01-22 | 2003-01-23 | 3SS+6d | 0d |
| 5 | 1.4 | beg.grond metselen 2e slag |  | 7d | 2003-01-23 | 2003-01-29 | 4SS+1d | 0d |
| 6 | 1.5 | dakbalklaag leggen |  | 4d | 2003-01-28 | 2003-01-31 | 5SS+5d | 0d |
| 7 | 1.6 | start gevel/dak fase | milestone | 0d | 2003-01-31 | 2003-01-31 | 6SS+4d | 0d |
